# planning_final

Schedule from MS Project, 2007-05-29 to 2007-06-18, 7 hours a day.
ADEA

## Calendars

- Standard: Mon-Fri 09:00-12:00, 14:00-18:00; Sat-Sun off.

## Resources

| Resource |
| --- |
| formation.continue |
| kevin.remy |
| stephane.leprince |
| bernard.terrier |
| dominique.cottanceau |
| thierry.le.van |
| jacqueline.buffard |
| patrick.perrard |
| Adrien MINOT |
| stephane.Adrien MINOT |

## Schedule

| ID | WBS | Task | Duration | Start | Finish | Predecessors | Total slack | Free slack | Resources | Work |
| --- | --- | --- | --- | --- | --- | --- | --- | --- | --- | --- |
| 1 | 1 | **Remise en service et test Logiciel CACES** | 0.67d? | 2007-05-29 09:00 | 2007-05-29 15:40 |  | 10.93d |  | formation.continue; jacqueline.buffard; Adrien MINOT | 28h |
| 2 | 1.1 | Entretien avec future utilisatrice | 0.67d? | 2007-05-29 09:00 | 2007-05-29 15:40 |  | 8.58d |  | formation.continue; jacqueline.buffard; Adrien MINOT | 14h |
| 3 | 2 | **Préparation** | 5.6d? | 2007-05-29 09:00 | 2007-06-05 15:12 |  | 0d |  | Adrien MINOT; stephane.leprince | 438.55h |
| 4 | 2.1 | Planification des tâches du stage | 1d | 2007-05-29 09:00 | 2007-05-29 18:00 |  | 0d |  | Adrien MINOT; stephane.leprince | 14h |
| 5 | 2.2 | **Schématisation des informations et plan du site** | 4.6d? | 2007-05-30 09:00 | 2007-06-05 15:12 |  | 2.85d |  | Adrien MINOT | 56.7h |
| 6 | 2.2.1 | Consultation du site actuel (front) | 0.25d | 2007-05-30 09:00 | 2007-05-30 10:45 | 4 | 7d | 3.25d | Adrien MINOT | 1.75h |
| 7 | 2.2.2 | Consultation du site actuel (back Office) | 0.25d | 2007-05-30 09:00 | 2007-05-30 10:45 | 4 | 8d |  | Adrien MINOT | 1.75h |
| 8 | 2.2.3 | Veille: recherche logiciel cartographie site web open source | 0.25d | 2007-05-30 09:00 | 2007-05-30 10:45 | 4 | 5.5d | 0d | Adrien MINOT | 1.75h |
| 9 | 2.2.4 | Cartographie du site actuel | 0.5d | 2007-05-30 10:45 | 2007-05-30 16:15 | 8 | 5.5d | 3.25d | Adrien MINOT | 3.5h |
| 10 | 2.2.5 | Recherche et Instalation d'un logiciel de modélisation de base de données | 0.5d | 2007-05-30 09:00 | 2007-05-30 14:30 | 4 | 9.35d | 0d | Adrien MINOT | 3.5h |
| 11 | 2.2.6 | Modélisation base données (estimation) | 0.75d | 2007-05-30 14:30 | 2007-05-31 10:45 | 10 | 7d |  | Adrien MINOT | 5.25h |
| 12 | 2.2.7 | Création liste des catégories et sections du futur site | 1d? | 2007-06-04 15:12 | 2007-06-05 15:12 | 9, 26 | 0d |  | Adrien MINOT | 7h |
| 13 | 2.3 | **Comparatif d'hebergeurs** | 2.2d? | 2007-05-30 09:00 | 2007-06-01 10:24 | 4 | 0.4d |  | Adrien MINOT; stephane.leprince; bernard.terrier; dominique.cottanceau; kevin.remy | 96.25h |
| 14 | 2.3.1 | informations sur contrat hébergement actuel | 0.25d | 2007-05-30 09:00 | 2007-05-30 10:45 | 4 | 7.85d | 0d | Adrien MINOT | 1.75h |
| 15 | 2.3.2 | Consultations sur Internet des offres de plusieurs hébergeurs | 1d? | 2007-05-30 09:00 | 2007-05-30 18:00 | 4 | 0.4d | 0d | Adrien MINOT | 7h |
| 16 | 2.3.3 | Etude sur les possibilités de continuité de service du site | 0.5d | 2007-05-30 09:00 | 2007-05-30 14:30 | 4 | 0.9d | 0.5d | Adrien MINOT | 3.5h |
| 17 | 2.3.4 | Choix du nouvel hébergeur et abonnement | 0.2d? | 2007-05-31 09:00 | 2007-05-31 10:24 | 4, 15, 16 | 0.4d | 0d | Adrien MINOT; stephane.leprince; bernard.terrier; dominique.cottanceau; kevin.remy | 7h |
| 18 | 2.3.5 | Démarrage de l'abonnement | 1d? | 2007-05-31 10:24 | 2007-06-01 10:24 | 17 | 0.4d | 0d |  |  |
| 19 | 2.4 | **Enquête utilisateurs du site** | 3.6d? | 2007-05-30 09:00 | 2007-06-04 15:12 | 4 | 0d |  | Adrien MINOT; stephane.leprince; stephane.Adrien MINOT; bernard.terrier; dominique.cottanceau; kevin.remy | 193.2h |
| 20 | 2.4.1 | Enquête auteurs | 1d? | 2007-05-30 09:00 | 2007-05-30 18:00 | 4 | 0d |  | Adrien MINOT | 7h |
| 21 | 2.4.2 | Enquête stagiaires | 1d? | 2007-05-30 09:00 | 2007-05-30 18:00 | 4 | 0d |  | Adrien MINOT | 7h |
| 22 | 2.4.3 | Enquête salariés | 1d? | 2007-05-30 09:00 | 2007-05-30 18:00 | 4 | 0d |  | Adrien MINOT | 7h |
| 23 | 2.4.4 | Taitement des réponses et statistiques | 1d? | 2007-05-31 09:00 | 2007-05-31 18:00 | 4, 20, 21, 22 | 0d |  | Adrien MINOT | 7h |
| 24 | 2.4.5 | Détermination des priorités et objectifs | 0.5d | 2007-06-01 09:00 | 2007-06-01 14:30 | 23 | 0d |  | Adrien MINOT | 3.5h |
| 25 | 2.4.6 | Préparation d'un compte rendu Powerpoint | 1d? | 2007-06-01 14:30 | 2007-06-04 14:30 | 24 | 0d |  | Adrien MINOT | 7h |
| 26 | 2.4.7 | Présentation des résultats de l'enquête | 0.1d | 2007-06-04 14:30 | 2007-06-04 15:12 | 25 | 0d |  | Adrien MINOT; stephane.leprince; bernard.terrier; dominique.cottanceau; kevin.remy | 3.5h |

Notes:
- 16: Chercher si il existe une solution de secours si l'hébergeur tombe en panne. Comment assurer l'accès au site quelque soit la situation

| ID | WBS | Task | Duration | Start | Finish | Predecessors | Total slack | Free slack | Resources | Work |
| --- | --- | --- | --- | --- | --- | --- | --- | --- | --- | --- |
| 27 | 3 | **Developpement** | 11.6d? | 2007-05-30 09:00 | 2007-06-14 15:12 | 4 | 2d |  | Adrien MINOT | 661.15h |
| 28 | 3.1 | Mise en place d'une plate-forme Joomla | 0.5d | 2007-06-01 10:24 | 2007-06-01 15:54 | 18 | 0.4d | 0d | Adrien MINOT | 3.5h |
| 29 | 3.2 | Création catégories | 0.5d | 2007-06-05 15:12 | 2007-06-06 09:42 | 12, 28 | 0d |  | Adrien MINOT | 3.5h |
| 30 | 3.3 | Création sections | 0.5d | 2007-06-06 09:42 | 2007-06-06 15:12 | 29 | 0d |  | Adrien MINOT | 3.5h |
| 31 | 3.4 | **Création articles** | 6d | 2007-06-06 15:12 | 2007-06-14 15:12 | 30 | 0d |  | Adrien MINOT; stephane.leprince | 126h |
| 32 | 3.4.1 | Import données anciens site vers nouveau | 6d | 2007-06-06 15:12 | 2007-06-14 15:12 | 30 | 0d |  | Adrien MINOT | 42h |
| 33 | 3.5 | Mise en place d'une sauvegarde automatisée | 1.5d | 2007-06-01 15:54 | 2007-06-05 10:24 | 28 | 0.4d | 0d | Adrien MINOT | 10.5h |
| 34 | 3.6 | Proposer des nouveautées pour le site | 1d? | 2007-05-30 09:00 | 2007-05-30 18:00 | 4 | 9.6d |  | Adrien MINOT | 7h |
| 35 | 3.7 | Rechercher et télécharger les composants adaptés | 0.5d? | 2007-05-30 09:00 | 2007-05-30 14:30 | 4 | 10.1d |  | Adrien MINOT; stephane.leprince | 7h |
| 36 | 3.8 | **Création des utilisateurs dans Joomla** | 2.25d | 2007-06-05 15:54 | 2007-06-07 17:39 | 60 | 0.4d | 0d | Adrien MINOT; stephane.leprince | 63h |
| 37 | 3.8.1 | Test importation active directory | 2d | 2007-06-05 15:54 | 2007-06-07 15:54 | 60 | 0.4d | 0d | Adrien MINOT; stephane.leprince | 28h |
| 38 | 3.8.2 | Importation | 0.25d | 2007-06-07 15:54 | 2007-06-07 17:39 | 37 | 0.4d |  | Adrien MINOT; stephane.leprince | 3.5h |
| 39 | 3.9 | **Création template** | 6.1d | 2007-06-04 14:30 | 2007-06-12 15:12 | 25 | 1d |  | Adrien MINOT | 333.2h |
| 40 | 3.9.1 | Comprendre les templates existants et autoformation | 2d | 2007-06-04 14:30 | 2007-06-06 14:30 | 4 | 1d | 0d | Adrien MINOT | 14h |
| 41 | 3.9.2 | Préparation esquisse templates | 0.5d | 2007-06-04 14:30 | 2007-06-04 18:00 | 25 | 2.5d | 1.5d | Adrien MINOT | 3.5h |
| 42 | 3.9.3 | Création fichier templates.php | 1.5d | 2007-06-06 14:30 | 2007-06-07 18:00 | 40, 41, 54 | 1d | 0d | Adrien MINOT | 10.5h |
| 43 | 3.9.4 | **Charte graphique** | 6.1d | 2007-06-04 14:30 | 2007-06-12 15:12 | 4 | 1d |  | Adrien MINOT; stephane.leprince; bernard.terrier; dominique.cottanceau; kevin.remy | 253.75h |
| 44 | 3.9.4.1 | Détermination d'un jeu de couleur | 0.38d | 2007-06-04 14:30 | 2007-06-04 17:07 | 6 | 4.12d | 3.12d | Adrien MINOT; stephane.leprince | 5.25h |
| 45 | 3.9.4.2 | Graphismes et retouches | 2d | 2007-06-04 14:30 | 2007-06-06 14:30 | 6, 24 | 2.5d | 1.5d | Adrien MINOT | 14h |
| 46 | 3.9.4.3 | La feuille de style CSS | 2d | 2007-06-08 09:00 | 2007-06-11 18:00 | 4, 44, 45, 40, 42, 54 | 1d | 0d | Adrien MINOT | 14h |
| 47 | 3.9.4.4 | Création fichier identification du template XML | 0.25d | 2007-06-06 14:30 | 2007-06-06 16:15 | 40 | 4.85d |  | Adrien MINOT | 1.75h |
| 48 | 3.9.4.5 | Création vignette du template | 0.25d | 2007-06-12 11:27 | 2007-06-12 15:12 | 50 | 1d |  | Adrien MINOT | 1.75h |
| 49 | 3.9.4.6 | Présentation des templates | 0.1d | 2007-06-12 09:00 | 2007-06-12 09:42 | 42, 46, 45 | 1d | 0d | Adrien MINOT; stephane.leprince; bernard.terrier; dominique.cottanceau; kevin.remy | 3.5h |
| 50 | 3.9.5 | Validation du template | 0.25d | 2007-06-12 09:42 | 2007-06-12 11:27 | 49 | 1d | 0d | Adrien MINOT; stephane.leprince; bernard.terrier; dominique.cottanceau; kevin.remy | 8.75h |

| ID | WBS | Task | Duration | Start | Finish | Predecessors | Total slack | Free slack | Resources | Work |
| --- | --- | --- | --- | --- | --- | --- | --- | --- | --- | --- |
| 51 | 3.10 | **Téléchargement et installation des composants** | 0.5d | 2007-06-05 15:54 | 2007-06-06 10:24 | 60 | 1.55d |  | Adrien MINOT | 22.75h |
| 52 | 3.10.1 | **Choix d'un composant de création de statistiques** | 0.5d | 2007-06-05 15:54 | 2007-06-06 10:24 | 60 | 5.4d |  | Adrien MINOT | 7h |
| 53 | 3.10.1.1 | Installation et test du composant | 0.5d | 2007-06-05 15:54 | 2007-06-06 10:24 | 60 | 5.4d |  | Adrien MINOT | 3.5h |
| 54 | 3.10.2 | Installation JoomExplorer | 0.25d | 2007-06-05 15:54 | 2007-06-05 17:39 | 60 | 1.55d | 0.55d | Adrien MINOT | 1.75h |
| 55 | 3.10.3 | **Choix composant utilisateurs lien avec AD** | 0.5d | 2007-06-05 15:54 | 2007-06-06 10:24 | 60 | 5.4d |  | Adrien MINOT; stephane.leprince | 10.5h |
| 56 | 3.10.3.1 | Installation et test du composant | 0.5d | 2007-06-05 15:54 | 2007-06-06 10:24 | 60 | 5.4d |  | Adrien MINOT | 3.5h |
| 57 | 4 | **Tests** | 8.4d? | 2007-06-05 10:24 | 2007-06-15 15:12 | 4 | 1d |  | Adrien MINOT | 106.05h |
| 58 | 4.1 | **Test sauvegarde** | 0.5d | 2007-06-05 10:24 | 2007-06-05 15:54 | 33 | 0.4d |  | Adrien MINOT | 10.5h |
| 59 | 4.1.1 | Test création fichiers sauvegardes | 0.5d | 2007-06-05 10:24 | 2007-06-05 15:54 | 33 | 5.9d |  | Adrien MINOT | 3.5h |
| 60 | 4.1.2 | Test remontée des informations | 0.5d | 2007-06-05 10:24 | 2007-06-05 15:54 | 33 | 0.4d | 0d | Adrien MINOT | 3.5h |
| 61 | 4.2 | **Test des droits d'accès** | 0.5d | 2007-06-07 15:54 | 2007-06-08 10:24 | 60 | 0.65d |  | Adrien MINOT | 10.5h |
| 62 | 4.2.1 | Test possibilité d'édition des articles en fonction de leur identifiant | 0.25d | 2007-06-07 17:39 | 2007-06-08 10:24 | 36 | 0.4d | 0d | Adrien MINOT | 1.75h |
| 63 | 4.2.2 | Test zone accès membres | 0.25d | 2007-06-07 17:39 | 2007-06-08 10:24 | 36 | 3.4d |  | Adrien MINOT | 1.75h |
| 64 | 4.2.3 | Tests identification active directory | 0.5d | 2007-06-07 15:54 | 2007-06-08 10:24 | 37 | 3.4d |  | Adrien MINOT | 3.5h |
| 65 | 4.3 | Tests des liens | 1d? | 2007-06-14 15:12 | 2007-06-15 15:12 | 31 | 1d |  | Adrien MINOT | 7h |
| 66 | 4.4 | **Tests mise en page** | 1d? | 2007-06-14 15:12 | 2007-06-15 15:12 | 32 | 0d |  | Adrien MINOT | 19.25h |
| 67 | 4.4.1 | Test firefox | 0.25d | 2007-06-14 15:12 | 2007-06-14 16:57 | 32 | 0.75d |  | Adrien MINOT | 1.75h |
| 68 | 4.4.2 | Test Safari | 0.25d | 2007-06-14 15:12 | 2007-06-14 16:57 | 32 | 0.75d |  | Adrien MINOT | 1.75h |
| 69 | 4.4.3 | Test IE | 0.25d | 2007-06-14 15:12 | 2007-06-14 16:57 | 32 | 0.75d |  | Adrien MINOT | 1.75h |
| 70 | 4.4.4 | Tests de visvilité sur les moteurs de recherche à partir de mots clés | 1d? | 2007-06-14 15:12 | 2007-06-15 15:12 | 4 | 0d |  | Adrien MINOT | 7h |
| 71 | 5 | **Corrections et améliorations** | 1d? | 2007-06-15 15:12 | 2007-06-18 15:12 | 66 | 0d |  | Adrien MINOT | 14h |
| 72 | 5.1 | Corrections des bugs navigateurs | 1d? | 2007-06-15 15:12 | 2007-06-18 15:12 | 66 | 0d |  | Adrien MINOT | 7h |
| 73 | 6 | **Récupération nom de domaine** | 1.5d | 2007-05-30 10:45 | 2007-05-31 16:15 |  | 7.85d |  | Adrien MINOT; stephane.leprince | 35h |
| 74 | 6.1 | demande de récupération nom de domaine | 0.5d | 2007-05-30 10:45 | 2007-05-30 16:15 | 14 | 7.85d | 0d | Adrien MINOT; stephane.leprince | 7h |
| 75 | 6.2 | Redirection du domaine | 0.5d | 2007-05-30 16:15 | 2007-05-31 10:45 | 74 | 7.85d | 0d | Adrien MINOT | 3.5h |
| 76 | 6.3 | Mise en ligne du nouveau site | 0.5d | 2007-05-31 10:45 | 2007-05-31 16:15 | 75 | 7.85d | 0d | Adrien MINOT | 3.5h |

Notes:
- 70: A voir si le deuxième nom de domaine n'est pas une contrainte pour les moteurs de recherche

| ID | WBS | Task | Type | Duration | Start | Finish | Predecessors | Total slack | Free slack | Resources | Work |
| --- | --- | --- | --- | --- | --- | --- | --- | --- | --- | --- | --- |
| 77 | 7 | **Promotion du site** |  | 1d? | 2007-05-31 16:15 | 2007-06-01 16:15 | 76 | 7.85d |  | Adrien MINOT | 35h |
| 78 | 7.1 | **Référencement** |  | 1d? | 2007-05-31 16:15 | 2007-06-01 16:15 | 4 | 7.85d |  | Adrien MINOT | 28h |
| 79 | 7.1.1 | Détermination liste de mots clés |  | 0.75d | 2007-05-31 16:15 | 2007-06-01 14:30 | 4 | 8.1d |  | Adrien MINOT | 5.25h |
| 80 | 7.1.2 | Récupération liste mot clé à partir code source ancien site |  | 0.25d | 2007-05-31 16:15 | 2007-05-31 18:00 | 4 | 8.6d |  | Adrien MINOT | 1.75h |
| 81 | 7.1.3 | Positionnement des mots clés dans les pages Joomla |  | 1d? | 2007-05-31 16:15 | 2007-06-01 16:15 | 4 | 7.85d |  | Adrien MINOT | 7h |
| 82 | 7.1.4 | Inscription annuaires |  | 1d? | 2007-05-31 16:15 | 2007-06-01 16:15 | 4 | 7.85d |  | Adrien MINOT | 7h |
| 83 | 8 | **Formation aux utilisateurs** |  | 10.2d? | 2007-05-30 09:00 | 2007-06-13 10:24 | 4 | 0.4d |  | Adrien MINOT | 195.3h |
| 84 | 8.1 | **Rédaction de tutoriels** |  | 8.2d? | 2007-05-30 09:00 | 2007-06-11 10:24 | 4 | 0.4d | 0d | Adrien MINOT | 109.9h |
| 85 | 8.1.1 | pour les salariés |  | 2d | 2007-05-30 09:00 | 2007-05-31 18:00 | 4 | 6.6d |  | Adrien MINOT | 14h |
| 86 | 8.1.2 | **pour les admins** |  | 3.5d? | 2007-06-05 15:54 | 2007-06-11 10:24 | 4 | 0.4d |  | Adrien MINOT | 38.5h |
| 87 | 8.1.2.1 | Tutos sur remontée des sauvegardes |  | 1d? | 2007-06-05 15:54 | 2007-06-06 15:54 | 60 | 2.9d |  | Adrien MINOT | 7h |
| 88 | 8.1.2.2 | Tutos sur la création d'articles |  | 1d? | 2007-06-08 10:24 | 2007-06-11 10:24 | 62 | 0.4d |  | Adrien MINOT | 7h |
| 89 | 8.2 | démonstrations personnalisées |  | 2d | 2007-06-11 10:24 | 2007-06-13 10:24 | 84 | 0.4d |  | Adrien MINOT | 14h |
| 90 | 9 | **Préparations pour la soutenance** |  | 9.75d? | 2007-05-30 09:00 | 2007-06-12 16:15 | 4 | 0.85d |  | Adrien MINOT; stephane.leprince | 350h |
| 91 | 9.1 | Rédaction du blog | milestone | 1d? | 2007-05-30 09:00 | 2007-05-30 18:00 | 4 | 9.6d |  | Adrien MINOT | 7h |
| 92 | 9.2 | **Mémoire** |  | 7.5d? | 2007-05-30 09:00 | 2007-06-08 14:30 | 4 | 0.85d |  | Adrien MINOT; stephane.leprince | 161h |
| 93 | 9.2.1 | Rédaction |  | 7d | 2007-05-30 09:00 | 2007-06-07 18:00 | 4 | 0.85d | 0d | Adrien MINOT | 49h |
| 94 | 9.2.2 | Relecture et corrections |  | 0.5d? | 2007-06-08 09:00 | 2007-06-08 14:30 | 93 | 0.85d | 0d | Adrien MINOT; stephane.leprince | 7h |
| 95 | 9.3 | **Préparation soutenance blanche** |  | 1.75d | 2007-06-08 14:30 | 2007-06-12 10:45 |  | 0.85d |  | Adrien MINOT; stephane.leprince | 38.5h |
| 96 | 9.3.1 | Création powerpoint soutenance |  | 1.5d | 2007-06-08 14:30 | 2007-06-11 18:00 | 94 | 0.85d | 0d | Adrien MINOT | 10.5h |
| 97 | 9.3.2 | Mise au point avec tuteur |  | 0.25d | 2007-06-12 09:00 | 2007-06-12 10:45 | 96 | 0.85d | 0d | Adrien MINOT; stephane.leprince | 3.5h |
| 98 | 9.4 | Soutenance Blanche |  | 0.5d | 2007-06-12 10:45 | 2007-06-12 16:15 | 97 | 0.85d |  | Adrien MINOT; stephane.leprince | 7h |
| 99 | 10 | Autres tâches |  | 1d? | 2007-05-30 09:00 | 2007-05-30 18:00 | 4 | 9.6d |  | Adrien MINOT | 7h |
